# SoftDev

Schedule from MS Project, 2004-01-01 to 2004-05-20.

## Calendars

- Estándar: Mon-Fri 09:00-13:00, 15:00-19:00; Sat-Sun off.

## Resources

| Resource |
| --- |
| Administración |
| Jefe de proyecto |
| Analista |
| Desarrollador |
| Personal de pruebas |
| Instructor |
| Escritores técnicos |
| Grupo de implantación |
| Especificador de Requerimientos |

## Schedule

| ID | WBS | Task | Type | Duration | Start | Finish | Predecessors | Total slack | Free slack | Resources | Work |
| --- | --- | --- | --- | --- | --- | --- | --- | --- | --- | --- | --- |
| 1 | 1 | **Definición del Proyecto** |  | 2.5d | 2004-01-01 | 2004-01-05 |  | 97.75d |  |  | 20h |
| 2 | 1.1 | Determinar el entorno del proyecto |  | 4h | 2004-01-01 | 2004-01-01 |  | 89.75d | 0d | Administración | 4h |
| 3 | 1.2 | Definir recursos preliminares |  | 1d | 2004-01-01 | 2004-01-02 | 2 | 89.75d | 0d | Jefe de proyecto | 8h |
| 4 | 1.3 | Aprobación por los patrocinadores |  | 1d | 2004-01-02 | 2004-01-05 | 3 | 89.75d | 0d | Jefe de proyecto | 8h |
| 5 | 1.4 | Definición del Proyecto Terminada | milestone | 0d | 2004-01-05 | 2004-01-05 | 4 | 89.75d |  | Jefe de proyecto |  |
| 6 | 2 | **Especificación de Requerimientos de Software** |  | 17d? | 2004-01-01 | 2004-01-23 |  | 0d |  |  | 136h |
| 7 | 2.1 | Realizar análisis de necesidades |  | 5d | 2004-01-01 | 2004-01-07 |  | 0d |  | Analista | 40h |
| 8 | 2.2 | Borrador de las especificaciones preliminares del software |  | 3d | 2004-01-08 | 2004-01-12 | 7 | 0d |  | Analista | 24h |
| 9 | 2.3 | Ingreso de datos al Sistema de Administración de Requerimientos] |  | 1d? | 2004-01-13 | 2004-01-13 | 8 | 0d |  |  |  |
| 10 | 2.4 | Desarrollar presupuesto preliminar |  | 2d | 2004-01-14 | 2004-01-15 | 9 | 0d |  | Jefe de proyecto | 16h |
| 11 | 2.5 | Revisar las especificaciones del software |  | 4h | 2004-01-16 | 2004-01-16 | 10 | 0d |  | Jefe de proyecto; Analista | 8h |
| 12 | 2.6 | Incorporar los comentarios a las especificaciones del software |  | 1d | 2004-01-16 | 2004-01-19 | 11 | 0d |  | Analista | 8h |
| 13 | 2.7 | Estimar los tiempos y fechas de entrega |  | 1d | 2004-01-19 | 2004-01-20 | 12 | 0d |  | Jefe de proyecto | 8h |
| 14 | 2.8 | Obtener aprobaciones para continuar (concepto, fechas, presupuestos) |  | 4h | 2004-01-20 | 2004-01-20 | 13 | 0d |  | Administración; Jefe de proyecto | 8h |
| 15 | 2.9 | Conseguir los recursos necesarios |  | 1d | 2004-01-21 | 2004-01-21 | 14 | 0d |  | Jefe de proyecto | 8h |
| 16 | 2.10 | Especificación Terminada |  | 1d | 2004-01-22 | 2004-01-22 | 15 | 0d |  | Jefe de proyecto | 8h |
| 17 | 2.11 | Refinamiento del Plan del Proyecto |  | 1d | 2004-01-23 | 2004-01-23 | 16 | 80.25d |  | Jefe de proyecto | 8h |
| 18 | 2.12 | Detalle del Cronograma [Fase: Elaboración] |  | 1d? | 2004-01-01 | 2004-01-01 |  | 96.25d |  |  |  |
| 19 | 3 | **Análisis** |  | 1d? | 2004-01-23 | 2004-01-23 | 16 | 0d |  |  | 8h |
| 20 | 3.1 | Generar Listado de Prioridad de los Casos de Uso |  | 1d? | 2004-01-23 | 2004-01-23 |  | 0d |  |  |  |
| 21 | 3.2 | Elaborar el Análisis de los Casos de Uso |  | 1d? | 2004-01-23 | 2004-01-23 |  | 0d |  | Analista | 8h |
| 22 | 3.3 | Definifir de las Unidades de Software |  | 1d? | 2004-01-23 | 2004-01-23 |  | 0d |  |  |  |
| 23 | 3.4 | Identificar los Roles Involucrados |  | 1d? | 2004-01-23 | 2004-01-23 |  | 0d |  |  |  |
| 24 | 3.5 | Elaborar el Diagrama de Descomposición Funcional |  | 1d? | 2004-01-23 | 2004-01-23 |  | 0d |  |  |  |
| 25 | 3.6 | Elaborar el Modelo Entidad Relación |  | 1d? | 2004-01-23 | 2004-01-23 |  | 0d |  |  |  |
| 26 | 3.7 | Diagramas de Actividades [UML] |  | 1d? | 2004-01-23 | 2004-01-23 |  | 0d |  |  |  |
| 27 | 3.8 | Documentación del Proceso de Análisis |  | 1d? | 2004-01-23 | 2004-01-23 |  | 0d |  |  |  |
| 28 | 3.9 | Revisión por Pares |  | 1d? | 2004-01-23 | 2004-01-23 |  | 0d |  |  |  |
| 29 | 3.10 | Reunión con los Usuarios |  | 1d? | 2004-01-23 | 2004-01-23 |  | 0d |  |  |  |
| 30 | 3.11 | Aprobación del Análisis |  | 1d? | 2004-01-23 | 2004-01-23 |  | 0d |  |  |  |

| ID | WBS | Task | Type | Duration | Start | Finish | Predecessors | Total slack | Resources | Work |
| --- | --- | --- | --- | --- | --- | --- | --- | --- | --- | --- |
| 31 | 4 | **Diseño** |  | 15.5d? | 2004-01-26 | 2004-02-16 |  | 0d |  | 120h |
| 32 | 4.1 | Especificaciones preliminares del software |  | 2d | 2004-01-26 | 2004-01-27 | 19 | 0d | Analista | 16h |
| 33 | 4.2 | Desarrollar especificaciones de funcionamiento |  | 5d | 2004-01-28 | 2004-02-03 | 32 | 0d | Analista | 40h |
| 34 | 4.3 | Desarrollar el Prototipo |  | 4d | 2004-02-04 | 2004-02-09 | 33 | 0d | Analista | 32h |
| 35 | 4.4 | Revisar especificaciones de funcionamiento |  | 2d | 2004-02-10 | 2004-02-11 | 34 | 0d | Administración | 16h |
| 36 | 4.5 | Incorporar comentarios a las especificaciones de funcionamiento |  | 1d | 2004-02-12 | 2004-02-12 | 35 | 0d | Administración | 8h |
| 37 | 4.6 | Obtener aprobación para continuar |  | 4h | 2004-02-13 | 2004-02-13 | 36 | 0d | Administración; Jefe de proyecto | 8h |
| 38 | 4.7 | Ingreso de Datos al Sistema de Administración de las Aplicaciones [Gestión de Objetos] |  | 1d? | 2004-02-13 | 2004-02-16 | 37 | 0d |  |  |
| 39 | 4.8 | Diseño Terminado | milestone | 0d | 2004-02-16 | 2004-02-16 | 38 | 0d |  |  |
| 40 | 5 | **Desarrollo** |  | 22.75d? | 2004-02-16 | 2004-03-18 |  | 0d |  | 264h |
| 41 | 5.1 | Revisar especificaciones de funcionamiento |  | 1d | 2004-02-16 | 2004-02-17 | 39 | 0d | Desarrollador | 8h |
| 42 | 5.2 | Identificar parámetros de diseño modular y de componentes separados |  | 1d | 2004-02-17 | 2004-02-18 | 41 | 0d | Desarrollador | 8h |
| 43 | 5.3 | Asignar el personal de desarrollo |  | 1d | 2004-02-18 | 2004-02-19 | 42 | 0d | Desarrollador | 8h |
| 44 | 5.4 | **Programación** |  | 16d? | 2004-02-19 | 2004-03-12 | 43 | 0d |  | 120h |
| 45 | 5.4.1 | Código en la Base de Datos |  | 1d? | 2004-02-19 | 2004-02-20 |  | 60.75d |  |  |
| 46 | 5.4.2 | **Código en la Herramienta de Desarrollo** |  | 16d? | 2004-02-19 | 2004-03-12 |  | 0d |  | 120h |
| 47 | 5.4.2.1 | **Modulo 001 [Reemplazar porel nombre correcto]** |  | 1d? | 2004-02-19 | 2004-02-20 |  | 63.75d |  |  |
| 48 | 5.4.2.1.1 | Unidad de Software 001 [Reemplazar por el nombre del Objeto] |  | 1d? | 2004-02-19 | 2004-02-20 |  | 60.75d |  |  |
| 49 | 5.4.2.1.2 | Unidad de Software 002 [Reemplazar por el nombre del Objeto] |  | 1d? | 2004-02-19 | 2004-02-20 |  | 60.75d |  |  |
| 50 | 5.4.2.2 | **Modulo 002 [Reemplazar porel nombre correcto]** |  | 16d? | 2004-02-19 | 2004-03-12 |  | 0d |  | 120h |
| 51 | 5.4.2.2.1 | Unidad de Software 003 [Reemplazar por el nombre del Objeto] |  | 1d? | 2004-02-19 | 2004-02-20 |  | 0d |  |  |
| 52 | 5.4.2.2.2 | Unidad de Software 004 [Reemplazar por el nombre del Objeto] |  | 15d | 2004-02-20 | 2004-03-12 | 51 | 0d | Desarrollador | 120h |
| 53 | 5.5 | Pruebas de los desarrolladores (depuración primaria) |  | 15d | 2004-02-26 | 2004-03-18 | 52FS-7.5% | 0d | Desarrollador | 120h |
| 54 | 5.6 | Desarrollo completado | milestone | 0d | 2004-03-18 | 2004-03-18 | 53 | 0d |  |  |

| ID | WBS | Task | Type | Duration | Start | Finish | Predecessors | Total slack | Free slack | Resources | Work |
| --- | --- | --- | --- | --- | --- | --- | --- | --- | --- | --- | --- |
| 55 | 6 | **Pruebas** |  | 49.75d | 2004-02-16 | 2004-04-26 |  | 18d |  |  | 280h |
| 56 | 6.1 | Desarrollar planes de pruebas de unidades usando las especificaciones del producto |  | 4d | 2004-02-16 | 2004-02-20 | 39 | 18.75d |  | Personal de pruebas | 32h |
| 57 | 6.2 | Desarrollar planes de pruebas de integración usando las especificaciones del producto |  | 4d | 2004-02-16 | 2004-02-20 | 39 | 60.75d |  | Personal de pruebas | 32h |
| 58 | 6.3 | **Pruebas de unidades** |  | 15d | 2004-03-18 | 2004-04-08 |  | 0d |  |  | 120h |
| 59 | 6.3.1 | Revisar el código modular |  | 5d | 2004-03-18 | 2004-03-25 | 56, 54 | 0d |  | Personal de pruebas | 40h |
| 60 | 6.3.2 | Probar si los módulos de los componentes se ajustan a las especificaciones del producto |  | 2d | 2004-03-25 | 2004-03-29 | 54, 59 | 0d |  | Personal de pruebas | 16h |
| 61 | 6.3.3 | Identificar anomalías y anotarlas en las especificaciones del producto |  | 3d | 2004-03-29 | 2004-04-01 | 60 | 0d |  | Personal de pruebas | 24h |
| 62 | 6.3.4 | Modificar código |  | 3d | 2004-04-01 | 2004-04-06 | 61 | 0d |  | Personal de pruebas | 24h |
| 63 | 6.3.5 | Volver a probar el código modificado |  | 2d | 2004-04-06 | 2004-04-08 | 62 | 0d |  | Personal de pruebas | 16h |
| 64 | 6.3.6 | Pruebas de unidades completadas | milestone | 0d | 2004-04-08 | 2004-04-08 | 63 | 0d |  |  |  |
| 65 | 6.4 | **Pruebas de integración** |  | 12d | 2004-04-08 | 2004-04-26 |  | 0d |  |  | 96h |
| 66 | 6.4.1 | Probar la integración de los módulos |  | 5d | 2004-04-08 | 2004-04-15 | 64 | 0d |  | Personal de pruebas | 40h |
| 67 | 6.4.2 | Identificar anomalías y anotarlas en las especificaciones |  | 2d | 2004-04-15 | 2004-04-19 | 66 | 0d |  | Personal de pruebas | 16h |
| 68 | 6.4.3 | Modificar código |  | 3d | 2004-04-19 | 2004-04-22 | 67 | 0d |  | Personal de pruebas | 24h |
| 69 | 6.4.4 | Volver a probar el código modificado |  | 2d | 2004-04-22 | 2004-04-26 | 68 | 0d |  | Personal de pruebas | 16h |
| 70 | 6.4.5 | Pruebas de integración completadas | milestone | 0d | 2004-04-26 | 2004-04-26 | 69 | 0d |  |  |  |
| 71 | 7 | **Capacitación** |  | 46.75d | 2004-02-16 | 2004-04-21 |  | 3d |  |  | 256h |
| 72 | 7.1 | Desarrollar las especificaciones de formación para los usuarios finales |  | 3d | 2004-02-16 | 2004-02-19 | 39 | 22.75d | 19.75d | Instructor | 24h |
| 73 | 7.2 | Desarrollar las especificaciones de formación para el personal de soporte al cliente |  | 3d | 2004-02-16 | 2004-02-19 | 39 | 22.75d | 19.75d | Instructor | 24h |
| 74 | 7.3 | Identificar la metodología de formación (utilizando PC, aulas, etc.) |  | 2d | 2004-02-16 | 2004-02-18 | 39 | 23.75d | 20.75d | Instructor | 16h |
| 75 | 7.4 | Desarrollar materiales de formación |  | 3w | 2004-03-18 | 2004-04-08 | 72, 54, 73, 74 | 3d | 0d | Instructor | 120h |
| 76 | 7.5 | Realizar estudio de posibilidades de uso de la formación |  | 4d | 2004-04-08 | 2004-04-14 | 75 | 3d | 0d | Instructor | 32h |
| 77 | 7.6 | Finalizar los materiales de formación |  | 3d | 2004-04-14 | 2004-04-19 | 76 | 3d | 0d | Instructor | 24h |
| 78 | 7.7 | Desarrollar mecanismo para impartir la formación |  | 2d | 2004-04-19 | 2004-04-21 | 77 | 3d | 0d | Instructor | 16h |
| 79 | 7.8 | Materiales de formación terminados | milestone | 0d | 2004-04-21 | 2004-04-21 | 78 | 3d |  | Instructor |  |

| ID | WBS | Task | Type | Duration | Start | Finish | Predecessors | Total slack | Free slack | Resources | Work |
| --- | --- | --- | --- | --- | --- | --- | --- | --- | --- | --- | --- |
| 80 | 8 | **Documentación** |  | 31.5d | 2004-02-16 | 2004-03-30 |  | 18.25d |  |  | 336h |
| 81 | 8.1 | Desarrollar las especificaciones de la ayuda |  | 1d | 2004-02-16 | 2004-02-17 | 39 | 28.75d | 10.5d | Escritores técnicos | 8h |
| 82 | 8.2 | Desarrollar el sistema de ayuda |  | 3w | 2004-03-03 | 2004-03-23 | 81, 52FS-5% | 18.25d | 0d | Escritores técnicos | 120h |
| 83 | 8.3 | Revisar la documentación de la ayuda |  | 3d | 2004-03-24 | 2004-03-26 | 82 | 18.25d | 0d | Escritores técnicos | 24h |
| 84 | 8.4 | Incorporar los comentarios a la documentación de la ayuda |  | 2d | 2004-03-29 | 2004-03-30 | 83 | 18.25d | 0d | Escritores técnicos | 16h |
| 85 | 8.5 | Desarrollar las especificaciones de los manuales de usuario |  | 2d | 2004-02-16 | 2004-02-18 | 39 | 28.75d | 9.5d | Escritores técnicos | 16h |
| 86 | 8.6 | Desarrollar los manuales de usuario |  | 3w | 2004-03-03 | 2004-03-23 | 85, 52FS-5% | 19.25d | 0d | Escritores técnicos | 120h |
| 87 | 8.7 | Revisar toda la documentación para el usuario |  | 2d | 2004-03-24 | 2004-03-25 | 86 | 19.25d | 0d | Escritores técnicos | 16h |
| 88 | 8.8 | Incorporar comentarios a la documentación de usuario |  | 2d | 2004-03-26 | 2004-03-29 | 87 | 19.25d | 1d | Escritores técnicos | 16h |
| 89 | 8.9 | Documentación completada | milestone | 0d | 2004-03-30 | 2004-03-30 | 88, 84 | 18.25d |  |  |  |
| 90 | 9 | **Fase piloto** |  | 73.25d | 2004-01-23 | 2004-05-05 |  | 0d |  |  | 64h |
| 91 | 9.1 | Designar grupo de pruebas |  | 1d | 2004-01-23 | 2004-01-23 | 16 | 64.25d | 0d | Jefe de proyecto | 8h |
| 92 | 9.2 | Desarrollar el mecanismo de entrega del software |  | 1d | 2004-01-26 | 2004-01-26 | 91 | 64.25d |  |  |  |
| 93 | 9.3 | Instalar y distribuir el software |  | 1d | 2004-04-26 | 2004-04-27 | 70, 92, 89, 79 | 0d |  | Grupo de implantación | 8h |
| 94 | 9.4 | Obtener comentarios de los usuarios |  | 1w | 2004-04-27 | 2004-05-04 | 93 | 0d |  | Grupo de implantación | 40h |
| 95 | 9.5 | Evaluar la información de las pruebas |  | 1d | 2004-05-04 | 2004-05-05 | 94 | 0d |  | Grupo de implantación | 8h |
| 96 | 9.6 | Fase piloto completada | milestone | 0d | 2004-05-05 | 2004-05-05 | 95 | 0d |  | Grupo de implantación |  |
| 97 | 10 | **Implantación** |  | 8d? | 2004-05-05 | 2004-05-17 |  | 0d |  |  | 64h |
| 98 | 10.1 | Determinar la estrategia final de distribución |  | 1d | 2004-05-05 | 2004-05-06 | 96 | 0d |  | Grupo de implantación | 8h |
| 99 | 10.2 | Desarrollar la metodología de distribución |  | 1d | 2004-05-06 | 2004-05-07 | 98 | 0d |  | Grupo de implantación | 8h |
| 100 | 10.3 | Afianzar recursos de implantación |  | 1d | 2004-05-07 | 2004-05-10 | 99 | 0d |  | Grupo de implantación | 8h |
| 101 | 10.4 | Dar formación al personal de soporte |  | 1d | 2004-05-10 | 2004-05-11 | 100 | 0d |  | Grupo de implantación | 8h |
| 102 | 10.5 | Distribuir el software |  | 1d | 2004-05-11 | 2004-05-12 | 101 | 0d |  | Grupo de implantación | 8h |
| 103 | 10.6 | Ejecución de Scripts |  | 1d? | 2004-05-12 | 2004-05-13 | 102 | 0d |  | Grupo de implantación | 8h |
| 104 | 10.7 | Transferencia de Archivos al Servidor de Aplicaciones |  | 1d? | 2004-05-13 | 2004-05-14 | 103 | 0d |  | Grupo de implantación | 8h |
| 105 | 10.8 | Creación de Usuarios en Base de Datos y Portal |  | 1d? | 2004-05-14 | 2004-05-17 | 104 | 0d |  | Grupo de implantación | 8h |
| 106 | 10.9 | Implantación Terminada | milestone | 0d | 2004-05-17 | 2004-05-17 | 105 | 0d |  | Grupo de implantación |  |

| ID | WBS | Task | Type | Duration | Start | Finish | Predecessors | Total slack | Resources | Work |
| --- | --- | --- | --- | --- | --- | --- | --- | --- | --- | --- |
| 107 | 11 | **Revisión posterior a la implementación** |  | 3d | 2004-05-17 | 2004-05-20 |  | 0d |  | 24h |
| 108 | 11.1 | Documentar la experiencia adquirida |  | 1d | 2004-05-17 | 2004-05-18 | 106 | 0d | Jefe de proyecto | 8h |
| 109 | 11.2 | Distribuir a los integrantes del equipo |  | 1d | 2004-05-18 | 2004-05-19 | 108 | 0d | Jefe de proyecto | 8h |
| 110 | 11.3 | Crear equipo de mantenimiento del software |  | 1d | 2004-05-19 | 2004-05-20 | 109 | 0d | Jefe de proyecto | 8h |
| 111 | 11.4 | Revisión posterior a la implementación | milestone | 0d | 2004-05-20 | 2004-05-20 | 110 | 0d | Jefe de proyecto |  |
| 112 | 12 | Plan terminado | milestone | 0d | 2004-05-20 | 2004-05-20 | 111 | 0d |  |  |
